# CONST SIST. AGUA POT. LINARES-CHANCADORA (POJO)

Schedule from MS Project, 2004-08-18 to 2005-02-17.
IMC LTDA.

## Calendars

- Estándar: Mon-Fri 08:00-14:00, 15:00-17:00; Sat-Sun off. Exceptions (off unless hours are given): 2004-06-01 to 2005-01-31 08:00-14:00, 15:00-17:00.

## Schedule

| ID | WBS | Task | Duration | Start | Finish | Predecessors | Total slack | Free slack |
| --- | --- | --- | --- | --- | --- | --- | --- | --- |
| 1 | 1 | **MOVILIZACIÓN** | 1d | 2004-08-18 | 2004-08-18 |  | 0d |  |
| 2 | 1.1 | MOVILIZACIÓN | 1d | 2004-08-18 | 2004-08-18 |  | 0d |  |
| 3 | 2 | **CONEXIONES DOMICILIARIAS** | 14d | 2004-12-29 | 2005-01-11 | 25 | 33d |  |
| 4 | 2.1 | PROV. E INST. CONEXIÓN DOMICILIARIA SEG. DISÑO. | 14d | 2004-12-29 | 2005-01-11 |  | 33d |  |
| 5 | 3 | **OBRA DE TOMA** | 20d | 2004-08-25 | 2004-09-13 |  | 0d |  |
| 6 | 3.1 | EXCAVACIÒN DE 0-2 M SUELO SEMIDURO | 1d | 2004-08-26 | 2004-08-26 | 13 | 0d |  |
| 7 | 3.2 | HORMIGÓN ARMADO - LOSAS (EST. CORR.) | 10d | 2004-08-30 | 2004-09-08 | 11 | 0d |  |
| 8 | 3.3 | REVOQUE DE MORTERO CON ADITIVO | 1d | 2004-09-09 | 2004-09-09 | 7 | 0d |  |
| 9 | 3.4 | PROV. Y COLOC. TAPA MET. (SEGÚN DISEÑO) | 2d | 2004-09-11 | 2004-09-12 | 10 | 0d |  |
| 10 | 3.5 | PROVISIÓN Y COLOCACIÓN ACCESORIOS OBRA DE TOMA | 1d | 2004-09-10 | 2004-09-10 | 8 | 0d |  |
| 11 | 3.6 | HORMIGÓN CICLÓPEO (50% PIEDRA) | 3d | 2004-08-27 | 2004-08-29 | 6 | 0d |  |
| 12 | 3.7 | PROVISIÓN Y COLOC. FILTROS GRADUADOS | 5d | 2004-08-30 | 2004-09-03 | 11 | 163d |  |
| 13 | 3.8 | REPLANTEO OBRA DE TOMA | 1d | 2004-08-25 | 2004-08-25 | 49 | 0d |  |
| 14 | 3.9 | CERCO DE ALAMBRE DE PUAS SEG/DISEÑO | 5d | 2004-08-30 | 2004-09-03 | 11 | 163d |  |
| 15 | 3.10 | ENTREGA | 1d | 2004-09-13 | 2004-09-13 | 9 | 0d |  |
| 16 | 4 | **RED DE DISTRIBUCIÓN** | 90d | 2004-11-13 | 2005-02-14 |  | 0d |  |
| 17 | 4.1 | REPLANTEO Y CONTROL DE LINEAS DE TUBERÍA | 10d | 2004-11-13 | 2004-11-22 | 78 | 0d |  |
| 18 | 4.2 | EXCAVACIÓN DE 0-2 M SUELO BLANDO | 15d | 2004-11-23 | 2004-12-07 | 17 | 0d |  |
| 19 | 4.3 | RELLENO COMPACTADO MANUAL-NO INC. MAT. | 16d | 2005-01-23 | 2005-02-09 | 43 | 0d |  |
| 20 | 4.4 | PROV. Y TENDIDO TUBERÍA PVC 3/4 PULG -ESQ.40 (ESP) | 15d | 2004-12-08 | 2004-12-22 | 18 | 33d | 0d |
| 21 | 4.5 | PROV. Y TENDIDO TUBERÍA PVC 1 PULG -ESQ.40 (ESPIG) | 15d | 2004-12-08 | 2004-12-22 | 20SS | 33d | 0d |
| 22 | 4.6 | PROV. Y TENDIDO TUBERÍA F.G. 3 PULG | 10d | 2004-12-08 | 2004-12-17 | 18 | 58d |  |
| 23 | 4.7 | PRUEBA HIDRÁULICA-TUBERÍAS HASTA 4 PULG. | 12d | 2005-01-05 | 2005-01-16 | 29 | 0d |  |
| 24 | 4.8 | DESINFECCIÓN DE TUEBRÍAS (HASTA D=4 PULG) | 12d | 2005-01-05 | 2005-01-16 | 29, 23FF | 0d |  |
| 25 | 4.9 | PROVISIÓN Y COLOC. ACCESORIOS RED DE DIST. | 6d | 2004-12-23 | 2004-12-28 | 21 | 33d | 0d |
| 26 | 4.10 | PROV. Y COLOC. TUB PVC SDR21 D=1 1/2" | 12d | 2004-12-08 | 2004-12-19 | 18 | 0d |  |
| 27 | 4.11 | PROV. Y COLOC TUBERÍA PVC D= 2 1/2" SDR21 | 16d | 2004-12-20 | 2005-01-04 | 28 | 0d |  |
| 28 | 4.12 | PROV. Y COLOC TUBERÍA PVC D= 2" SDR21 | 12d | 2004-12-08 | 2004-12-19 | 18, 26FF | 0d |  |
| 29 | 4.13 | PROV. Y COLOC TUBERÍA PVC D= 3" SDR21 | 16d | 2004-12-20 | 2005-01-04 | 28, 27FF | 0d |  |
| 30 | 4.14 | PROV. Y COLOC TUBERÍA PVC D= 4" SDR21 | 12d | 2004-12-20 | 2004-12-31 | 28 | 44d |  |
| 31 | 4.15 | CÁMARA DE LLAVES 2" SEG/DISEÑO, INCLUYE ACCES. | 6d | 2005-01-17 | 2005-01-22 | 24 | 0d |  |
| 32 | 4.16 | PASO DE QUEBRADA SEG/DISEÑO L=25M D=1 1/2" | 10d | 2004-12-23 | 2005-01-01 | 21 | 43d | 0d |
| 33 | 4.17 | PASO DE QUEBRADA SEG/DISEÑO L=10M D=2" | 10d | 2004-12-23 | 2005-01-01 | 32SS | 43d | 0d |
| 34 | 4.18 | PASO DE QUEBRADA SEG/DISEÑO L=19M D=2" | 10d | 2004-12-23 | 2005-01-01 | 33SS | 43d | 0d |
| 35 | 4.19 | PASO DE QUEBRADA SEG/DISEÑO L=25M D=2" | 10d | 2004-12-23 | 2005-01-01 | 34SS | 43d | 0d |
| 36 | 4.20 | PASO DE QUEBRADA SEG/DISEÑO L=15M D=2 1/2" | 10d | 2004-12-23 | 2005-01-01 | 35SS | 43d | 0d |
| 37 | 4.21 | PASO DE QUEBRADA SEG/DISEÑO L=20M D=2 1/2" | 10d | 2004-12-23 | 2005-01-01 | 36SS | 43d | 0d |
| 38 | 4.22 | PASO DE QUEBRADA SEG/DISEÑO L=25M D=2 1/2" | 10d | 2004-12-23 | 2005-01-01 | 37SS | 43d | 0d |
| 39 | 4.23 | PASO DE QUEBRADA SEG/DISEÑO L=15M D=4" | 10d | 2004-12-23 | 2005-01-01 | 38SS | 43d | 0d |
| 40 | 4.24 | CÁMARA DE LLAVES 1" SEG/DISEÑO, INCLUYE ACCES. | 6d | 2005-01-17 | 2005-01-22 | 24, 31SS | 0d |  |
| 41 | 4.25 | CÁMARA DE LLAVES 1 1/2" SEG/DISEÑO, INCLUYE ACCES | 6d | 2005-01-17 | 2005-01-22 | 40SS | 22d |  |
| 42 | 4.26 | CÁMARA DE LLAVES 2 1/2" SEG/DISEÑO, INCLUYE ACCES | 6d | 2005-01-17 | 2005-01-22 | 40SS | 0d |  |
| 43 | 4.27 | CÁMARA DE LLAVES 3" SEG/DISEÑO, INCLUYE ACCES. | 6d | 2005-01-17 | 2005-01-22 | 42SS | 0d |  |
| 44 | 4.28 | CÁMARA DE PURGA 1" SEG/DISEÑO, INCLUYE ACCES. | 4d | 2005-01-17 | 2005-01-20 | 24 | 24d |  |
| 45 | 4.29 | PASO DE QUEBRADA SEG/DISEÑO L=6M D=1 1/2" | 10d | 2004-12-23 | 2005-01-01 | 39SS | 43d |  |
| 46 | 4.30 | ENTREGA | 3d | 2005-02-10 | 2005-02-14 | 19 | 0d |  |

| ID | WBS | Task | Duration | Start | Finish | Predecessors | Total slack | Free slack | Constraint |
| --- | --- | --- | --- | --- | --- | --- | --- | --- | --- |
| 47 | 5 | **TRABAJOS PRELIMINARES** | 6d | 2004-08-19 | 2004-08-24 |  | 0d |  |  |
| 48 | 5.1 | PROV. Y COLOC LETRERO DE OBRAS | 6d | 2004-08-19 | 2004-08-24 | 2 | 0d |  |  |
| 49 | 5.2 | INSTALACIÓN DE FAENAS | 6d | 2004-08-19 | 2004-08-24 | 48SS | 0d |  |  |
| 50 | 6 | **ADUCCIÓN** | 45d | 2004-09-14 | 2004-10-28 |  | 108d |  |  |
| 51 | 6.1 | REPLANTEO Y CONTROL DE LINEAS DE TUBERÍA | 5d | 2004-09-14 | 2004-09-18 | 15 | 108d | 0d |  |
| 52 | 6.2 | EXCAVACIÓN DE 0-2 M SUELO BLANDO | 3d | 2004-09-19 | 2004-09-21 | 51 | 108d | 0d |  |
| 53 | 6.3 | RELLENO COMPACTADO MANUAL - NO INC. MAT. | 12d | 2004-10-14 | 2004-10-25 | 55 | 108d | 0d |  |
| 54 | 6.4 | PRUEBA HIDRÁULICA - TUBERÍAS HASTA 4 PULG. | 14d | 2004-10-12 | 2004-10-25 | 53FF, 58 | 111d |  | start no earlier than 2004-07-25 |
| 55 | 6.5 | DESINFECCIÓN DE TUBERÍAS (HASTA D=4 PULG.) | 2d | 2004-10-12 | 2004-10-13 | 58 | 108d | 0d |  |
| 56 | 6.6 | PROV. Y COLOC. TUBERÍA PVC D=2" SDR21 | 15d | 2004-09-22 | 2004-10-06 | 52 | 108d | 0d |  |
| 57 | 6.7 | PASO DE QUBRADA L=15 M SEG/DISÑO | 18d | 2004-09-22 | 2004-10-09 | 52 | 110d | 2d |  |
| 58 | 6.8 | CÁMARA VENTOSA 2" SEG/DISÑO, INCLUYE ACCES. | 5d | 2004-10-07 | 2004-10-11 | 56, 57FF | 108d | 0d |  |
| 59 | 6.9 | CÁMARA DE PURGA 2" SEG./DISÑO, INCLUYE ACCES. | 5d | 2004-10-07 | 2004-10-11 | 56, 58FF | 125d | 0d |  |
| 60 | 6.10 | PASO DE QUEBRADA L=10 M SEG/DISÑO | 15d | 2004-09-27 | 2004-10-11 | 52, 59FF | 125d |  |  |
| 61 | 6.11 | ENTREGA | 3d | 2004-10-26 | 2004-10-28 | 53 | 108d |  |  |
| 62 | 7 | **TANQUE DE ALMACENAMIENTO** | 60d | 2004-09-14 | 2004-11-12 |  | 0d |  |  |
| 63 | 7.1 | REPLANTEO DE ESTRUCTURAS ESP. Y ED. | 1d | 2004-09-14 | 2004-09-14 | 15 | 0d |  |  |
| 64 | 7.2 | EXCAVACIÓN DE 0-2 M SUELO SEMIDURO | 1d | 2004-09-15 | 2004-09-15 | 63 | 0d |  |  |
| 65 | 7.3 | BASE DE HORMIGÓN POBRE | 2d | 2004-09-16 | 2004-09-17 | 64 | 0d |  |  |
| 66 | 7.4 | HORMIGÓN SIMPLE - MUROS (EST. CORRIENTES) | 18d | 2004-09-18 | 2004-10-05 | 65 | 0d |  |  |
| 67 | 7.5 | HORMIGÓN ARMADO - LOSAS (EST. CORRIENTES) | 21d | 2004-10-20 | 2004-11-09 | 69 | 0d |  |  |
| 68 | 7.6 | ACERO ESTRUCTURAL FY=4200 KG/CM2 (GRADO 60) | 5d | 2004-09-16 | 2004-09-20 | 64 | 146d |  |  |
| 69 | 7.7 | REVOQUE DE MORTERO CON ADITIVO IMP. | 14d | 2004-10-06 | 2004-10-19 | 66 | 0d |  |  |
| 70 | 7.8 | PROV. Y COLOC. TAPA MET. E=1/8 (SEGÚN DISEÑO) | 2d | 2004-11-10 | 2004-11-11 | 67 | 0d |  |  |
| 71 | 7.9 | CERCO PERIMETRAL C/MALLA OLIMPICA SEG/DISÑO. | 5d | 2004-09-18 | 2004-09-22 | 65 | 144d |  |  |
| 72 | 7.10 | PROVISIÓN ESCALERA METÁLICA PORTATIL | 2d | 2004-10-06 | 2004-10-07 | 66 | 129d |  |  |
| 73 | 7.11 | HORMIGÓN CICLÓPEO (50% PIEDRA) | 10d | 2004-09-18 | 2004-09-27 | 65 | 139d | 0d |  |
| 74 | 7.12 | PROV. Y COLOC. HIPOCLORADOR | 3d | 2004-10-20 | 2004-10-22 | 69 | 114d |  |  |
| 75 | 7.13 | PROV. Y COLOC. ACCESORIOS TANQUE | 2d | 2004-11-10 | 2004-11-11 | 67, 70FF | 0d |  |  |
| 76 | 7.14 | PROV. Y COLOC. MACROMEDIDOR SEG/DISÑO, INC ACCES. | 3d | 2004-10-20 | 2004-10-22 | 69 | 114d |  |  |
| 77 | 7.15 | CASETA DE HIPOCLORADOR SEG/DISÑO. | 10d | 2004-09-18 | 2004-09-27 | 65, 73FF | 139d |  |  |
| 78 | 7.16 | ENTREGA | 1d | 2004-11-12 | 2004-11-12 | 75 | 0d |  |  |

| ID | WBS | Task | Duration | Start | Finish | Predecessors | Total slack |
| --- | --- | --- | --- | --- | --- | --- | --- |
| 79 | 8 | **ENTREGA FINAL** | 3d | 2005-02-15 | 2005-02-17 | 46 | 0d |
| 80 | 8.1 | ENTREGA | 3d | 2005-02-15 | 2005-02-17 |  | 0d |
| 81 | 8.2 | PROV. Y COLOC. PLACA ENTREGA DE OBRAS FPS | 1d | 2005-02-15 | 2005-02-15 | 80SS | 2d |
