# Supervisión - Const. Agua Pot

Schedule from MS Project, 2004-05-03 to 2004-11-28.
Ingeniero Civil

## Calendars

- Estándar: Mon-Fri 08:00-12:00, 13:00-17:00; Sat-Sun off. Exceptions (off unless hours are given): 2004-03-01 to 2006-01-31 09:00-13:00, 15:00-19:00.

## Schedule

| ID | WBS | Task | Type | Duration | Start | Finish | Predecessors | Baseline start | Baseline finish | Baseline duration | Total slack | Free slack | Constraint |
| --- | --- | --- | --- | --- | --- | --- | --- | --- | --- | --- | --- | --- | --- |
| 1 | 1 | ORDEN DE PROCEDER SUPERVISIÓN | milestone | 0d | 2004-05-03 | 2004-05-03 |  |  |  |  | 0d |  |  |
| 2 | 2 | INICIACIÓN DE SERVICIOS DE LA SUPERVISIÓN | milestone | 0d | 2004-05-03 | 2004-05-03 | 1 |  |  |  | 0d |  |  |
| 3 | 3 | GERENCIA Y SEGURIDAD DE CALIDAD DEL SERVICIO |  | 210d | 2004-05-03 | 2004-11-28 | 2 |  |  |  | 0d |  |  |
| 4 | 1 | **ACTIVIDADES GENERALES** |  | 210d | 2004-05-03 | 2004-11-28 |  |  |  |  | 0d |  |  |
| 5 | 1.1 | Coordinación y Administración del Proyecto |  | 210d | 2004-05-03 | 2004-11-28 |  |  |  |  | 0d |  | start no earlier than 2004-05-03 |
| 6 | 1.2 | Movilización |  | 1d | 2004-05-03 | 2004-05-03 |  | 2002-06-24 | 2002-06-25 | 2d | 209d |  | start no earlier than 2004-05-03 |
| 7 | 1.3 | Recopilación de la Información Existente |  | 2d | 2004-05-03 | 2004-05-04 |  | 2002-09-09 | 2002-09-22 | 14d | 208d |  | start no earlier than 2004-05-03 |
| 8 | 1.4 | Reconocimiento Inicial de Campo |  | 2d | 2004-05-03 | 2004-05-04 |  | 2002-09-16 | 2002-09-29 | 14d | 208d |  |  |
| 9 | 2 | **FASE DE REVISIÓN DEL DISEÑO FINAL** |  | 15d | 2004-05-03 | 2004-05-17 |  |  |  |  | 15d | 0d |  |
| 10 | 3 | REVISION DEL DISEÑO DEL PROYECTO |  | 15d | 2004-05-03 | 2004-05-17 | 2 |  |  |  | 15d |  |  |
| 11 | 5.2 | REVISIÓN DEL ESTUDIO HIDROLOGICO |  | 15d | 2004-05-03 | 2004-05-17 | 2 |  |  |  | 15d |  |  |
| 12 | 3.1 | **FASE REPLANTEO DEL EJE** |  | 15d | 2004-05-21 | 2004-06-04 |  |  |  |  | 177d |  |  |
| 13 | 3.1.1 | REPLANTEO LINEAS DE TUBERÍA Y TQ |  | 15d | 2004-05-21 | 2004-06-04 |  |  |  |  | 177d |  | start no earlier than 2004-05-21 |
| 14 | 3.2 | **SUPERVISIÓN DE OBRAS DE CONSTRUCCIÓN** |  | 180d | 2004-05-18 | 2004-11-13 |  |  |  |  | 15d |  |  |
| 15 | 7.1 | **CONTROL TECNICO ADMINISTRATIVO** |  | 180d | 2004-05-18 | 2004-11-13 |  |  |  |  | 15d |  |  |
| 16 | 7.1.1 | CONTROL DEL PROGRAMA DEL CONSTRUCTOR |  | 180d | 2004-05-18 | 2004-11-13 | 9 |  |  |  | 15d |  |  |
| 17 | 7.1.2 | CONTROL DEL PROGRAMA DE INVERSIONES |  | 180d | 2004-05-18 | 2004-11-13 | 9 |  |  |  | 15d |  |  |
| 18 | 7.1.3 | CONTROL DEL PROGRAMA DE MAQUINARIA |  | 180d | 2004-05-18 | 2004-11-13 | 9 |  |  |  | 15d |  |  |
| 19 | 7.1.4 | CONTROL DE ORDENES DE CAMBIO |  | 180d | 2004-05-18 | 2004-11-13 | 9 |  |  |  | 15d |  |  |
| 20 | 7.2 | **CONTROL Y SUPEVISIÓN DE LA CONSTRUCCIÓN** |  | 180d | 2004-05-18 | 2004-11-13 |  |  |  |  | 15d |  |  |
| 21 | 3.2.1 | CONTROL TOPOGRAFICO Y GEOMETRICO |  | 180d | 2004-05-18 | 2004-11-13 | 9 |  |  |  | 15d |  | start no earlier than 2003-09-16 |
| 22 | 7.2.2 | CONTROL DE CALIDAD DE MATERIALES |  | 180d | 2004-05-18 | 2004-11-13 | 9 |  |  |  | 15d |  |  |
| 23 | 3.2.2 | CONTROL MEJORA PAQUETE ESTRUCTURAL |  | 45d | 2004-05-18 | 2004-07-01 | 9 |  |  |  | 150d |  | start no earlier than 2003-09-22 |
| 24 | 3.2.3 | CONTROL DE OBRAS DE DRENAJE y ESTRUCTURAS |  | 45d | 2004-05-18 | 2004-07-01 | 9 |  |  |  | 150d |  | start no earlier than 2003-09-16 |
| 25 | 3.2.5 | CONTROL AMBIENTAL |  | 180d | 2004-05-18 | 2004-11-13 | 9 |  |  |  | 15d |  | start no earlier than 2003-09-16 |

Notes:
- 4: Duracion 45 dias
- 5: PLAZO DE 4 MESES

| ID | WBS | Task | Duration | Start | Finish | Total slack | Constraint |
| --- | --- | --- | --- | --- | --- | --- | --- |
| 26 | 3.3 | **FASE DE RECEPCIÓN Y LIQUIDACIÓN DE OBRA** | 5d | 2004-11-23 | 2004-11-27 | 1d |  |
| 27 | 3.3.1 | RECEPCIÓN Y LIQUIDACIÓN DE OBRA | 5d | 2004-11-23 | 2004-11-27 | 1d | start no earlier than 2004-11-23 |
